Schedule from MS Project, 2011-09-12 to 2012-01-09, A marks actual dates.

## Calendars

- Standard: Mon-Fri 08:00-12:00, 13:00-17:00; Sat-Sun off.

## Resources

| Resource |
| --- |
| Tim 9 |
| Skoda |
| Volentier |
| Poizl |
| Forus |
| Kujan, Toth |
| Aufricht |
| Toth |
| AKujan |
| Kujan |

## Schedule

| ID | WBS | Task | Type | Duration | Start | Finish | Predecessors | Complete | Remaining | Actual start | Total slack | Resources | Work | Actual work |
| --- | --- | --- | --- | --- | --- | --- | --- | --- | --- | --- | --- | --- | --- | --- |
| 1 | 1 | **Virtualna FIIT** |  | 86d | 2011-09-12 A | 2012-01-09 |  | 52% | 41.36d |  | 0d |  | 4584h | 2421.6h |
| 2 | 1.1 | **Preparations** |  | 16d | 2011-09-19 A | 2011-10-10 A |  | 100% |  |  |  |  | 640h | 640h |
| 3 | 1.1.1 | jabber konferencia |  | 16d | 2011-09-19 A | 2011-10-10 A |  | 100% |  |  |  | Forus | 128h | 128h |
| 4 | 1.1.2 | Klonovanie svn do git |  | 16d | 2011-09-19 A | 2011-10-10 A |  | 100% |  |  |  | Poizl | 128h | 128h |
| 5 | 1.1.3 | Vytvorenie redmine |  | 16d | 2011-09-19 A | 2011-10-10 A |  | 100% |  |  |  | Forus | 128h | 128h |
| 6 | 1.1.4 | webova prezentacia |  | 16d | 2011-09-19 A | 2011-10-10 A |  | 100% |  |  |  | Aufricht | 128h | 128h |
| 7 | 1.1.5 | Timove logo |  | 16d | 2011-09-19 A | 2011-10-10 A |  | 100% |  |  |  | Toth | 128h | 128h |
| 8 | 1.2 | **Implementation** |  | 66d | 2011-10-10 | 2012-01-09 |  | 45% | 36.27d | 2011-09-12 |  |  | 3896h | 1781.6h |
| 9 | 1.2.1 | **Scrum Sprints** |  | 42d | 2011-10-10 A | 2011-12-06 |  | 52% | 20.21d |  | 0d |  | 3368h | 1781.6h |
| 10 | 1.2.1.1 | **Sprint 1** |  | 13d | 2011-10-10 A | 2011-10-26 A |  | 100% |  |  |  |  | 968h | 968h |
| 11 | 1.2.1.1.1 | **Tasks** |  | 11d | 2011-10-10 A | 2011-10-24 A |  | 100% |  |  |  |  | 968h | 968h |
| 12 | 1.2.1.1.1.1 | Otestovat AIS importer |  | 11d | 2011-10-10 A | 2011-10-24 A |  | 100% |  |  |  | Kujan | 88h | 88h |
| 13 | 1.2.1.1.1.2 | Aktualizácia webovej prezentacie |  | 11d | 2011-10-10 A | 2011-10-24 A |  | 100% |  |  |  | Aufricht | 88h | 88h |
| 14 | 1.2.1.1.1.3 | Prejsť celú dokumentáciu |  | 11d | 2011-10-10 A | 2011-10-24 A |  | 100% |  |  |  | Tim 9 | 88h | 88h |
| 15 | 1.2.1.1.1.4 | Naštudovať 3D Studio MAX |  | 11d | 2011-10-10 A | 2011-10-24 A |  | 100% |  |  |  | Kujan, Toth | 88h | 88h |
| 16 | 1.2.1.1.1.5 | Vytvorenie plánu na semester |  | 11d | 2011-10-10 A | 2011-10-24 A |  | 100% |  |  |  | Volentier | 88h | 88h |
| 17 | 1.2.1.1.1.6 | Build skripty |  | 11d | 2011-10-10 A | 2011-10-24 A |  | 100% |  |  |  | Poizl | 88h | 88h |
| 18 | 1.2.1.1.1.7 | WebGL |  | 11d | 2011-10-10 A | 2011-10-24 A |  | 100% |  |  |  | Forus | 88h | 88h |
| 19 | 1.2.1.1.1.8 | Tiene + lightmapy, antialiasing |  | 11d | 2011-10-10 A | 2011-10-24 A |  | 100% |  |  |  | Poizl | 88h | 88h |
| 20 | 1.2.1.1.1.9 | Menovky na dverách |  | 11d | 2011-10-10 A | 2011-10-24 A |  | 100% |  |  |  | Volentier | 88h | 88h |
| 21 | 1.2.1.1.1.10 | Hľadanie bugov |  | 11d | 2011-10-10 A | 2011-10-24 A |  | 100% |  |  |  | Tim 9 | 88h | 88h |
| 22 | 1.2.1.1.1.11 | Analyzovať možnosti pre mobilneho klienta |  | 11d | 2011-10-10 A | 2011-10-24 A |  | 100% |  |  |  | Skoda | 88h | 88h |
| 23 | 1.2.1.1.2 | Testing | manual | 3d | 2011-10-24 A | 2011-10-26 A |  | 100% |  |  |  |  |  |  |
| 24 | 1.2.1.2 | **Sprint 2** |  | 13d | 2011-10-24 A | 2011-11-09 | 11 | 90% | 1.3d |  |  |  | 880h | 813.6h |
| 25 | 1.2.1.2.1 | **Tasks** |  | 11d | 2011-10-24 A | 2011-11-06 |  | 92% | 0.83d |  |  |  | 880h | 813.6h |
| 26 | 1.2.1.2.1.1 | Hľadanie nových bugov | manual | 11d | 2011-10-24 A | 2011-11-06 |  | 92% | 0.83d |  |  | Tim 9 | 88h | 81.36h |
| 27 | 1.2.1.2.1.2 | Oprava bugov | manual | 11d | 2011-10-24 A | 2011-11-06 |  | 92% | 0.83d |  |  | Tim 9 | 88h | 81.36h |
| 28 | 1.2.1.2.1.3 | Menovky – serverová strana | manual | 11d | 2011-10-24 A | 2011-11-06 |  | 92% | 0.83d |  |  | Aufricht | 88h | 81.36h |
| 29 | 1.2.1.2.1.4 | Upraviť vysúvací panel | manual | 11d | 2011-10-24 A | 2011-11-06 |  | 92% | 0.83d |  |  | Aufricht | 88h | 81.36h |
| 30 | 1.2.1.2.1.5 | 3D model | manual | 11d | 2011-10-24 A | 2011-11-06 |  | 92% | 0.83d |  |  | Kujan | 88h | 81.36h |
| 31 | 1.2.1.2.1.6 | Tiene + lightmapy, antialiasing | manual | 11d | 2011-10-24 A | 2011-11-06 |  | 92% | 0.83d |  |  | Toth | 88h | 81.36h |
| 32 | 1.2.1.2.1.7 | Analýza a vytvorenie natívnej mobilnej aplikácie | manual | 11d | 2011-10-24 A | 2011-11-06 |  | 92% | 0.83d |  |  | Forus | 88h | 81.36h |
| 33 | 1.2.1.2.1.8 | Menovky – klientská strana | manual | 11d | 2011-10-24 A | 2011-11-06 |  | 92% | 0.83d |  |  | Volentier | 88h | 81.36h |
| 34 | 1.2.1.2.1.9 | Mobilný klient - grafická navigácia | manual | 11d | 2011-10-24 A | 2011-11-06 |  | 92% | 0.83d |  |  | Skoda | 88h | 81.36h |
| 35 | 1.2.1.2.1.10 | Mobilný klient – textová navigácia | manual | 11d | 2011-10-24 A | 2011-11-06 |  | 92% | 0.83d |  |  | Poizl | 88h | 81.36h |
| 36 | 1.2.1.2.2 | Testing | manual | 3d | 2011-11-07 | 2011-11-09 |  |  |  |  |  |  |  |  |
| 37 | 1.2.1.3 | Odovzdanie dokumentácie analýzy | manual | 1d | 2011-11-10 | 2011-11-10 | 36 |  |  |  |  |  |  |  |

| ID | WBS | Task | Type | Duration | Start | Finish | Predecessors | Total slack | Free slack | Constraint | Resources | Work |
| --- | --- | --- | --- | --- | --- | --- | --- | --- | --- | --- | --- | --- |
| 38 | 1.2.1.4 | **Sprint 3** |  | 10d | 2011-11-10 | 2011-11-23 | 24 |  |  |  |  | 640h |
| 39 | 1.2.1.4.1 | **Tasks** |  | 8d | 2011-11-10 | 2011-11-21 |  |  |  |  |  | 640h |
| 40 | 1.2.1.4.1.1 | Menovky - klientská strana | manual | 8d | 2011-11-10 | 2011-11-21 |  |  |  |  | Volentier | 64h |
| 41 | 1.2.1.4.1.2 | Upraviť vysúvaci panel | manual | 8d | 2011-11-10 | 2011-11-21 |  |  |  |  | Aufricht | 64h |
| 42 | 1.2.1.4.1.3 | Analýza možnosti vytvorenia natívnej mobilnej aplikácie | manual | 8d | 2011-11-10 | 2011-11-21 |  |  |  |  | Forus | 64h |
| 43 | 1.2.1.4.1.4 | Oprava bugov – model | manual | 8d | 2011-11-10 | 2011-11-21 |  |  |  |  | Toth | 64h |
| 44 | 1.2.1.4.1.5 | Oprava bugov – kolízie | manual | 8d | 2011-11-10 | 2011-11-21 |  |  |  |  | Forus | 64h |
| 45 | 1.2.1.4.1.6 | Oprava bugov – prepojenie poschodí | manual | 8d | 2011-11-10 | 2011-11-21 |  |  |  |  | Volentier | 64h |
| 46 | 1.2.1.4.1.7 | Spustenie mobilnej verzie na localhoste | manual | 8d | 2011-11-10 | 2011-11-21 |  |  |  |  | Skoda | 64h |
| 47 | 1.2.1.4.1.8 | Nájdenie príkladu väčšej budovy vo WebGL | manual | 8d | 2011-11-10 | 2011-11-21 |  |  |  |  | Skoda | 64h |
| 48 | 1.2.1.4.1.9 | Redizajn webu | manual | 8d | 2011-11-10 | 2011-11-21 |  |  |  |  | Aufricht | 64h |
| 49 | 1.2.1.4.1.10 | Antialising | manual | 8d | 2011-11-10 | 2011-11-21 |  |  |  |  | Toth | 64h |
| 50 | 1.2.1.4.2 | testing | manual | 4d | 2011-11-20 | 2011-11-23 |  |  |  |  |  |  |
| 51 | 1.2.1.5 | **Sprint 4** |  | 12d | 2011-11-21 | 2011-12-06 | 38 |  |  |  |  | 880h |
| 52 | 1.2.1.5.1 | **Tasks** |  | 11d | 2011-11-21 | 2011-12-05 |  |  |  |  |  | 880h |
| 53 | 1.2.1.5.1.1 | Menovky - serverová strana | manual | 11d | 2011-11-21 | 2011-12-05 |  |  |  |  | Aufricht | 88h |
| 54 | 1.2.1.5.1.2 | Mobilný klient - grafická navigácia | manual | 11d | 2011-11-21 | 2011-12-05 |  |  |  |  | Skoda | 88h |
| 55 | 1.2.1.5.1.3 | Mobilný klient - textová navigácia | manual | 11d | 2011-11-21 | 2011-12-05 |  |  |  |  | Poizl | 88h |
| 56 | 1.2.1.5.1.4 | Oprava bugov – výťah | manual | 11d | 2011-11-21 | 2011-12-05 |  |  |  |  | Forus | 88h |
| 57 | 1.2.1.5.1.5 | Lightmapy | manual | 11d | 2011-11-21 | 2011-12-05 |  |  |  |  | Toth | 88h |
| 58 | 1.2.1.5.1.6 | Implementácia novej web stránky | manual | 11d | 2011-11-21 | 2011-12-05 |  |  |  |  | Aufricht | 88h |
| 59 | 1.2.1.5.1.7 | Neviditeľné zábradlia schodísk | manual | 11d | 2011-11-21 | 2011-12-05 |  |  |  |  | Kujan | 88h |
| 60 | 1.2.1.5.1.8 | Výškové mapy | manual | 11d | 2011-11-21 | 2011-12-05 |  |  |  |  | Toth | 88h |
| 61 | 1.2.1.5.1.9 | Optimalizácia menoviek | manual | 11d | 2011-11-21 | 2011-12-05 |  |  |  |  | Volentier | 88h |
| 62 | 1.2.1.5.1.10 | Redizajn webových prvkov | manual | 11d | 2011-11-21 | 2011-12-05 |  |  |  |  | Forus | 88h |
| 63 | 1.2.1.5.2 | Testing | manual | 3d | 2011-12-04 | 2011-12-06 |  |  |  |  |  |  |
| 64 | 1.2.2 | Finálna Documentácia |  | 66d | 2011-09-12 | 2011-12-12 |  | -1d | 0d | finish no earlier than 2011-12-12 | Skoda | 528h |

| ID | WBS | Task | Type | Duration | Start | Finish | Predecessors | Total slack | Constraint | Resources | Work |
| --- | --- | --- | --- | --- | --- | --- | --- | --- | --- | --- | --- |
| 65 | 1.3 | **Deployment** |  | 7d | 2011-12-12 | 2011-12-20 | 64 |  |  |  | 48h |
| 66 | 1.3.1 | odovzdanie prototypu | manual | 2d | 2011-12-12 | 2011-12-13 |  |  | finish no earlier than 2011-12-13 |  |  |
| 67 | 1.3.2 | používateľská prezentácia prototypu | manual | 6d | 2011-12-13 | 2011-12-20 |  |  |  | Tim 9 | 48h |
| 68 | 1.4 | Project finished | milestone | 0d | 2011-12-21 | 2011-12-21 | 67 | 14d | start no earlier than 2011-12-21 |  |  |
